# MINUS_Schedule_2008_1025

Schedule from MS Project, 2008-09-04 to 2008-12-01, A marks actual dates.
Booz Allen Hamilton

## Calendars

- Standard: Mon-Fri 08:00-12:00, 13:00-17:00; Sat-Sun off.

## Schedule

| ID | WBS | Task | Type | Duration | Start | Finish | Predecessors | Complete | Remaining | Baseline start | Baseline finish | Baseline duration | Total slack | Free slack | Constraint |
| --- | --- | --- | --- | --- | --- | --- | --- | --- | --- | --- | --- | --- | --- | --- | --- |
| 1 | 1 | **MINUS Research Schedule** |  | 63d? | 2008-09-04 A | 2008-12-01 |  | 44% | 35.55d? |  |  |  | 0d |  |  |
| 2 | 1.1 | **Prepare Proposal** |  | 6d | 2008-09-04 A | 2008-09-11 A |  | 100% |  | 2008-09-08 | 2008-09-11 | 0d? |  |  |  |
| 3 | 1.1.1 | Develop Project Scope |  | 5d | 2008-09-04 A | 2008-09-10 A |  | 100% |  |  |  |  |  |  | start no earlier than 2008-02-25 |
| 4 | 1.1.2 | Identify Stakeholders |  | 1.13d | 2008-09-04 A | 2008-09-11 A | 3 | 100% |  |  |  |  |  |  | finish no earlier than 2008-09-11 |
| 5 | 1.1.3 | Conduct Market Research |  | 6d | 2008-09-04 A | 2008-09-11 A | 4 | 100% |  |  |  |  |  |  | finish no earlier than 2008-09-11 |
| 6 | 1.2 | **Concept Development** |  | 18d | 2008-09-12 A | 2008-10-07 A | 5 | 100% |  |  |  |  |  |  |  |
| 7 | 1.2.1 | Draft System level CONOPS |  | 10d | 2008-09-12 A | 2008-09-25 A | 2 | 100% |  |  |  |  |  |  |  |
| 8 | 1.2.2 | Finalize CONOPS | milestone | 8d | 2008-09-26 A | 2008-10-07 A | 7 | 100% |  |  |  |  |  |  |  |
| 9 | 1.3 | **System Requirements** |  | 34d | 2008-09-12 A | 2008-10-29 | 2 | 69% | 10.5d |  |  |  | 23d |  |  |
| 10 | 1.3.1 | Define Problem |  | 2d | 2008-09-12 A | 2008-09-15 A | 2 | 100% |  |  |  |  |  |  |  |
| 11 | 1.3.2 | Identify Detailed System Objectives |  | 5d | 2008-09-16 A | 2008-09-22 A | 10 | 100% |  |  |  |  |  |  |  |
| 12 | 1.3.3 | Define Functions and Behavior of the System |  | 5d | 2008-09-23 A | 2008-09-29 | 11 | 75% | 1.25d |  |  |  | 13d | 0d |  |
| 13 | 1.3.4 | Develop System Requirements Document |  | 17d | 2008-09-30 A | 2008-10-22 | 12 | 75% | 4.25d |  |  |  | 23d | 0d |  |
| 14 | 1.3.5 | Finalize System Requirements Document | milestone | 5d | 2008-10-23 | 2008-10-29 | 13 |  |  |  |  |  | 23d |  |  |
| 15 | 1.4 | **System Design Specifcation** |  | 35d | 2008-09-30 A | 2008-11-17 | 12 | 20% | 28d |  |  |  | 10d |  |  |
| 16 | 1.4.1 | Develop Use Cases |  | 3d | 2008-09-30 A | 2008-10-02 A | 12 | 100% |  |  |  |  |  |  |  |
| 17 | 1.4.2 | Identify Hardware/Software Alternatives |  | 8d | 2008-10-03 A | 2008-10-14 | 16 | 50% | 4d |  |  |  | 0d |  |  |
| 18 | 1.4.3 | Cost Analysis |  | 5d | 2008-10-15 | 2008-10-21 | 17 |  |  |  |  |  | 0d |  |  |
| 19 | 1.4.4 | Determine Hardware/Software Components |  | 4d | 2008-10-22 | 2008-10-27 | 18 |  |  |  |  |  | 0d |  |  |
| 20 | 1.4.5 | Develop System Design Specification |  | 14d | 2008-10-28 | 2008-11-14 | 19 |  |  |  |  |  | 10d |  |  |
| 21 | 1.4.6 | Finalize System Design Specification | milestone | 1d | 2008-11-17 | 2008-11-17 | 20 |  |  |  |  |  | 10d |  |  |
| 22 | 1.5 | **Architecture Development** |  | 15d? | 2008-10-28 | 2008-11-17 | 19 |  |  |  |  |  | 10d |  |  |
| 23 | 1.5.1 | Develop Operational View (OV-1: High Level Operational Concept Graphic) |  | 4d | 2008-10-28 | 2008-10-31 | 19 |  |  |  |  |  | 10d | 0d |  |
| 24 | 1.5.2 | Develop Technical View (TV-1: Technical Architecture Profile) |  | 5d | 2008-11-03 | 2008-11-07 | 23 |  |  |  |  |  | 10d | 0d |  |
| 25 | 1.5.3 | Develop Systems View (SV-1: System Interface Description) |  | 5d | 2008-11-10 | 2008-11-14 | 24 |  |  |  |  |  | 10d | 0d |  |
| 26 | 1.5.4 | Finalize Architecture Views | milestone | 1d? | 2008-11-17 | 2008-11-17 | 25 |  |  |  |  |  | 10d |  |  |

| ID | WBS | Task | Type | Duration | Start | Finish | Predecessors | Total slack |
| --- | --- | --- | --- | --- | --- | --- | --- | --- |
| 27 | 1.6 | **Business Case Development** |  | 19d | 2008-10-28 | 2008-11-21 | 19 | 0d |
| 28 | 1.6.1 | Conduct Sensitivity Analysis |  | 4d | 2008-10-28 | 2008-10-31 | 19 | 0d |
| 29 | 1.6.2 | Conduct Risk Analysis |  | 4d | 2008-11-03 | 2008-11-06 | 28 | 0d |
| 30 | 1.6.3 | Develop Marketing Strategy |  | 4d | 2008-11-07 | 2008-11-12 | 29 | 0d |
| 31 | 1.6.4 | Finalize Business Case | milestone | 7d | 2008-11-13 | 2008-11-21 | 30 | 0d |
| 32 | 1.7 | **Project Report** |  | 6d | 2008-11-24 | 2008-12-01 | 31 | 0d |
| 33 | 1.7.1 | Consolidate deliverables into a single report |  | 1d | 2008-11-24 | 2008-11-24 | 31 | 0d |
| 34 | 1.7.2 | Finalize Report | milestone | 5d | 2008-11-25 | 2008-12-01 | 33 | 0d |
